# Project XXXX-XXXX

Schedule from MS Project, 2016-07-22 to 2019-06-05, status date 2015-03-23.
<enter project description>
State of Connecticut Dept of Transportation
<enter lead design unit> / <enter CLE name> / <enter task-based-consultant name>

## Calendars

- Standard: Mon-Fri 08:00-12:00, 13:00-17:00; Sat-Sun off.

## Resources

| Resource |
| --- |
| bruce |

## Schedule

| ID | WBS | Task | Type | Duration | Start | Finish | Predecessors | Total slack | Free slack |
| --- | --- | --- | --- | --- | --- | --- | --- | --- | --- |
| 1 | 1 | **Project Initiation Phase** |  | 260d | 2016-07-22 | 2017-07-21 |  | 0d |  |
| 2 | 1.1 | Prepare and Submit PPI |  | 120d | 2016-07-22 | 2017-01-06 |  | 0d |  |
| 3 | 1.2 | Prepare and Approve RPM |  | 80d | 2017-01-06 | 2017-04-28 | 2 | 0d |  |
| 4 | 1.3 | Secure Funding/Authorization |  | 60d | 2017-04-28 | 2017-07-21 | 3 | 0d |  |
| 5 | 2 | **Preliminary Design Phase** |  | 120d | 2017-07-21 | 2018-01-05 |  | 0d |  |
| 6 | 2.1 | Survey |  | 3mo | 2017-07-21 | 2017-10-13 | 4 | 60d |  |
| 7 | 2.2 | NEPA/CEPA |  | 120d | 2017-07-21 | 2018-01-05 | 4 | 0d |  |
| 8 | 2.3 | Preliminary Right-of-Way (ROW) Tasks |  | 120d | 2017-07-21 | 2018-01-05 | 4 | 0d |  |
| 9 | 2.4 | Permit Needs Determintation Form (PNDF) |  | 120d | 2017-07-21 | 2018-01-05 | 4 | 0d |  |
| 10 | 2.5 | Develop PD through Design Approval |  | 120d | 2017-07-21 | 2018-01-05 | 4 | 0d |  |
| 11 | 2.6 | Design Approval | milestone | 0d | 2018-01-05 | 2018-01-05 | 10, 7, 6, 8, 9 | 0d |  |
| 12 | 3 | **Final Design Phase** |  | 318d | 2018-01-05 | 2019-03-27 |  | 0d |  |
| 13 | 3.1 | Prepare Semi-Final Design Submission |  | 140d | 2018-01-05 | 2018-07-20 | 11 | 78d | 0d |
| 14 | 3.2 | Plan-In-Hand Review | milestone | 0mo | 2018-03-02 | 2018-03-02 | 13SS+2mo | 178d | 100d |
| 15 | 3.3 | Prepare Final Design Submission |  | 100d | 2018-07-20 | 2018-12-07 | 13, 14 | 78d |  |
| 16 | 3.4 | **ROW Coordination** |  | 255d | 2018-01-05 | 2018-12-28 |  | 63d |  |
| 17 | 3.4.1 | Prepare and Submit Property Maps |  | 80d | 2018-01-05 | 2018-04-27 | 11 | 118d | 55d |
| 18 | 3.4.2 | Acquire Properties - ROW Phase |  | 12mo | 2018-01-26 | 2018-12-28 | 11FS+3w, 17FF+6mo | 63d |  |
| 19 | 3.5 | **Permit Acquistion Process** |  | 318d | 2018-01-05 | 2019-03-27 |  | 0d |  |
| 20 | 3.5.1 | **Flood Management Certification (FMC)** |  | 275d | 2018-01-05 | 2019-01-25 |  | 43d |  |
| 21 | 3.5.1.1 | **Flood Management General Certification (CTDOT-H&D)** |  | 30d | 2018-01-05 | 2018-02-16 |  | 285d |  |
| 22 | 3.5.1.1.1 | Draft Memo Request |  | 10d | 2018-01-05 | 2018-01-19 | 11 | 285d | 0d |
| 23 | 3.5.1.1.2 | CTDOT H&D Review & Processing |  | 1mo | 2018-01-19 | 2018-02-16 | 22 | 285d |  |
| 24 | 3.5.1.2 | **Flood Management Certification for Municipal Projects-MOU (Municipality & CTDOT-H&D & OEP)** |  | 100d | 2018-01-05 | 2018-05-25 |  | 218d |  |
| 25 | 3.5.1.2.1 | Draft MOU Municipal Permit |  | 20d | 2018-01-05 | 2018-02-02 | 11 | 218d | 0d |
| 26 | 3.5.1.2.2 | CTDOT H&D Review |  | 1mo | 2018-02-02 | 2018-03-02 | 25 | 223d | 5d |
| 27 | 3.5.1.2.3 | CTDOT OEP Review |  | 1mo | 2018-02-02 | 2018-03-02 | 25 | 218d | 0d |
| 28 | 3.5.1.2.4 | CTDOT EPC Review |  | 1w | 2018-03-02 | 2018-03-09 | 27 | 218d | 0d |
| 29 | 3.5.1.2.5 | Draft Revisions to MOU Municipal Permit |  | 20d | 2018-03-09 | 2018-04-06 | 26, 28 | 218d | 0d |
| 30 | 3.5.1.2.6 | CTDOT H&D Review & Processing |  | 1mo | 2018-04-06 | 2018-05-04 | 29 | 218d | 0d |
| 31 | 3.5.1.2.7 | CTDOT OEP Review & Processing |  | 1mo | 2018-04-06 | 2018-05-04 | 29 | 218d | 0d |
| 32 | 3.5.1.2.8 | Engineering Bureau Chief Sign-Off |  | 1w | 2018-05-04 | 2018-05-11 | 30, 31 | 218d | 0d |
| 33 | 3.5.1.2.9 | Municipality Certification |  | 2w | 2018-05-11 | 2018-05-25 | 32 | 218d |  |

| ID | WBS | Task | Duration | Start | Finish | Predecessors | Total slack | Free slack |
| --- | --- | --- | --- | --- | --- | --- | --- | --- |
| 34 | 3.5.1.3 | **Individual Flood Management Certification (CTDEEP-IWRD)** | 175d | 2018-01-05 | 2018-09-07 |  | 140d |  |
| 35 | 3.5.1.3.1 | Draft Permit | 30d | 2018-01-05 | 2018-02-16 | 11 | 140d | 0d |
| 36 | 3.5.1.3.2 | CTDOT OEP Review | 2mo | 2018-02-16 | 2018-04-13 | 35 | 140d | 0d |
| 37 | 3.5.1.3.3 | CTDOT EPC Review | 1w | 2018-04-13 | 2018-04-20 | 36 | 140d | 0d |
| 38 | 3.5.1.3.4 | Draft Revisions to Permit | 20d | 2018-04-20 | 2018-05-18 | 37 | 140d | 0d |
| 39 | 3.5.1.3.5 | CTDOT OEP Review & Processing | 1mo | 2018-05-18 | 2018-06-15 | 38 | 140d | 0d |
| 40 | 3.5.1.3.6 | CTDEEP Review, Processing & Certification | 3mo | 2018-06-15 | 2018-09-07 | 39 | 140d |  |
| 41 | 3.5.1.4 | **Individual Flood Management Cert. with Exemption (CTDEEP-IWRD)** | 275d | 2018-01-05 | 2019-01-25 |  | 43d |  |
| 42 | 3.5.1.4.1 | Draft Permit | 30d | 2018-01-05 | 2018-02-16 | 11 | 43d | 0d |
| 43 | 3.5.1.4.2 | CTDOT OEP Review | 2mo | 2018-02-16 | 2018-04-13 | 42 | 43d | 0d |
| 44 | 3.5.1.4.3 | CTDOT EPC Review | 1w | 2018-04-13 | 2018-04-20 | 43 | 43d | 0d |
| 45 | 3.5.1.4.4 | Draft Revisions to Permit | 20d | 2018-04-20 | 2018-05-18 | 44 | 43d | 0d |
| 46 | 3.5.1.4.5 | CTDOT OEP Review & Processing | 1mo | 2018-05-18 | 2018-06-15 | 45 | 43d | 0d |
| 47 | 3.5.1.4.6 | CTDEEP Review & Processing | 6mo | 2018-06-15 | 2018-11-30 | 46 | 43d | 0d |
| 48 | 3.5.1.4.7 | Public Notice Period | 1mo | 2018-11-30 | 2018-12-28 | 47 | 43d | 0d |
| 49 | 3.5.1.4.8 | CTDEEP Permit Issuance | 1mo | 2018-12-28 | 2019-01-25 | 48 | 43d |  |
| 50 | 3.5.2 | **401 Water Quality Certification (WQC) (CTDEEP-IWRD)** | 275d | 2018-01-05 | 2019-01-25 |  | 40d |  |
| 51 | 3.5.2.1 | **CT Addendum USACE General Permit (CT GP)** | 215d | 2018-01-05 | 2018-11-02 |  | 100d |  |
| 52 | 3.5.2.1.1 | Draft Permit | 30d | 2018-01-05 | 2018-02-16 | 11 | 100d | 0d |
| 53 | 3.5.2.1.2 | CTDOT OEP Review | 1mo | 2018-02-16 | 2018-03-16 | 52 | 100d | 0d |
| 54 | 3.5.2.1.3 | CTDOT EPC Review | 1w | 2018-03-16 | 2018-03-23 | 53 | 100d | 0d |
| 55 | 3.5.2.1.4 | Draft Revisions to Permit | 20d | 2018-03-23 | 2018-04-20 | 54 | 100d | 0d |
| 56 | 3.5.2.1.5 | CTDOT OEP Review & Processing | 1mo | 2018-04-20 | 2018-05-18 | 55 | 100d | 0d |
| 57 | 3.5.2.1.6 | CTDEEP Review, Processing & Certification | 6mo | 2018-05-18 | 2018-11-02 | 56 | 100d |  |

| ID | WBS | Task | Duration | Start | Finish | Predecessors | Total slack | Free slack |
| --- | --- | --- | --- | --- | --- | --- | --- | --- |
| 58 | 3.5.2.2 | **Individual 401 WQC** | 275d | 2018-01-05 | 2019-01-25 |  | 40d |  |
| 59 | 3.5.2.2.1 | Draft Permit | 30d | 2018-01-05 | 2018-02-16 | 11 | 40d | 0d |
| 60 | 3.5.2.2.2 | CTDOT OEP Review | 2mo | 2018-02-16 | 2018-04-13 | 59 | 40d | 0d |
| 61 | 3.5.2.2.3 | CTDOT EPC Review | 1w | 2018-04-13 | 2018-04-20 | 60 | 40d | 0d |
| 62 | 3.5.2.2.4 | Draft Revisions to Permit | 20d | 2018-04-20 | 2018-05-18 | 61 | 40d | 0d |
| 63 | 3.5.2.2.5 | CTDOT OEP Review & Processing | 1mo | 2018-05-18 | 2018-06-15 | 62 | 40d | 0d |
| 64 | 3.5.2.2.6 | CTDEEP Review & Processing | 6mo | 2018-06-15 | 2018-11-30 | 63 | 40d | 0d |
| 65 | 3.5.2.2.7 | Public Notice Period | 1mo | 2018-11-30 | 2018-12-28 | 64 | 40d | 0d |
| 66 | 3.5.2.2.8 | CTDEEP Permit Issuance | 1mo | 2018-12-28 | 2019-01-25 | 65 | 40d |  |
| 67 | 3.5.3 | **Inland Wetlands/Watercourses Permits (CTDEEP-IWRD)** | 318d | 2018-01-05 | 2019-03-27 |  | 0d |  |
| 68 | 3.5.3.1 | **General Water Resource Construction Activities** | 318d | 2018-01-05 | 2019-03-27 |  | 0d |  |
| 69 | 3.5.3.1.1 | Draft Permit | 30d | 2018-01-05 | 2018-02-16 | 11 | 220d | 0d |
| 70 | 3.5.3.1.2 | CTDOT OEP Review | 1mo | 2018-02-16 | 2018-03-16 | 69 | 220d | 0d |
| 71 | 3.5.3.1.3 | CTDOT EPC Review | 1w | 2018-03-16 | 2018-03-23 | 70 | 220d | 0d |
| 72 | 3.5.3.1.4 | Draft Revisions to Permit | 20d | 2018-03-23 | 2018-04-20 | 71 | 220d | 0d |
| 73 | 3.5.3.1.5 | CTDOT OEP Review & Processing | 1mo | 2018-04-20 | 2018-05-18 | 72 | 220d |  |
| 74 | 3.5.3.1.6 | CTDOT OEP Permit Registration to CTDEEP | 3d | 2019-03-22 | 2019-03-27 | 23, 40, 57, 73, 156, 174, 66, 165, 133, 142, 149 | 0d |  |
| 75 | 3.5.3.2 | **Individual Inland Wetland & Watercourses** | 275d | 2018-01-05 | 2019-01-25 |  | 43d |  |
| 76 | 3.5.3.2.1 | Draft Permit | 30d | 2018-01-05 | 2018-02-16 | 11 | 43d | 0d |
| 77 | 3.5.3.2.2 | CTDOT OEP Review | 2mo | 2018-02-16 | 2018-04-13 | 76 | 43d | 0d |
| 78 | 3.5.3.2.3 | CTDOT EPC Review | 1w | 2018-04-13 | 2018-04-20 | 77 | 43d | 0d |
| 79 | 3.5.3.2.4 | Draft Revisions to Permit | 20d | 2018-04-20 | 2018-05-18 | 78 | 43d | 0d |
| 80 | 3.5.3.2.5 | CTDOT OEP Review & Processing | 1mo | 2018-05-18 | 2018-06-15 | 79 | 43d | 0d |
| 81 | 3.5.3.2.6 | CTDEEP Review & Processing | 6mo | 2018-06-15 | 2018-11-30 | 80 | 43d | 0d |
| 82 | 3.5.3.2.7 | Public Notice Period | 1mo | 2018-11-30 | 2018-12-28 | 81 | 43d | 0d |
| 83 | 3.5.3.2.8 | CTDEEP Permit Issuance | 1mo | 2018-12-28 | 2019-01-25 | 82 | 43d |  |

| ID | WBS | Task | Duration | Start | Finish | Predecessors | Total slack | Free slack |
| --- | --- | --- | --- | --- | --- | --- | --- | --- |
| 84 | 3.5.4 | **Stormwater Permit (CTDEEP-WPED)** | 150d | 2018-01-05 | 2018-08-03 |  | 168d |  |
| 85 | 3.5.4.1 | Draft Permit | 30d | 2018-01-05 | 2018-02-16 | 11 | 168d | 0d |
| 86 | 3.5.4.2 | On-Call-Consultant Review | 6w | 2018-02-16 | 2018-03-30 | 85 | 173d | 5d |
| 87 | 3.5.4.3 | CTDOT District Office Review & Processing | 6w | 2018-02-16 | 2018-03-30 | 85 | 173d | 5d |
| 88 | 3.5.4.4 | CTDOT OEP Review | 6w | 2018-02-16 | 2018-03-30 | 85 | 168d | 0d |
| 89 | 3.5.4.5 | CTDOT EPC Review | 1w | 2018-03-30 | 2018-04-06 | 88 | 168d | 0d |
| 90 | 3.5.4.6 | Draft Revisions to Permit | 20d | 2018-04-06 | 2018-05-04 | 86, 87, 89 | 168d | 0d |
| 91 | 3.5.4.7 | On-Call-Consultant Review | 1mo | 2018-05-04 | 2018-06-01 | 90 | 173d | 5d |
| 92 | 3.5.4.8 | CTDOT OEP Review & Processing | 1mo | 2018-05-04 | 2018-06-01 | 90 | 173d | 5d |
| 93 | 3.5.4.9 | CTDOT District Office Review & Signing | 5w | 2018-05-04 | 2018-06-08 | 90 | 168d | 0d |
| 94 | 3.5.4.10 | CTDEEP Review & Processing | 2mo | 2018-06-08 | 2018-08-03 | 91, 92, 93 | 168d |  |
| 95 | 3.5.5 | **Coastal Permits** | 281d | 2018-01-05 | 2019-02-04 |  | 37d |  |
| 96 | 3.5.5.1 | **Coastal Consistency Review -- Internal (CTDOT-OEP)** | 40d | 2018-01-05 | 2018-03-02 |  | 278d |  |
| 97 | 3.5.5.1.1 | Draft Review Request Form | 10d | 2018-01-05 | 2018-01-19 | 11 | 278d | 0d |
| 98 | 3.5.5.1.2 | CTDOT OEP Review & Processing | 6w | 2018-01-19 | 2018-03-02 | 97 | 278d |  |
| 99 | 3.5.5.2 | **Coastal Consistency Review (CTDEEP-OLSIP)** | 155d | 2018-01-05 | 2018-08-10 |  | 163d |  |
| 100 | 3.5.5.2.1 | Draft Review Request Form | 30d | 2018-01-05 | 2018-02-16 | 11 | 163d | 0d |
| 101 | 3.5.5.2.2 | CTDOT OEP Review | 1mo | 2018-02-16 | 2018-03-16 | 100 | 163d | 0d |
| 102 | 3.5.5.2.3 | CTDOT EPC Review | 1w | 2018-03-16 | 2018-03-23 | 101 | 163d | 0d |
| 103 | 3.5.5.2.4 | Draft Revisions to Permit | 20d | 2018-03-23 | 2018-04-20 | 102 | 163d | 0d |
| 104 | 3.5.5.2.5 | CTDOT OEP Review & Processing | 1mo | 2018-04-20 | 2018-05-18 | 103 | 163d | 0d |
| 105 | 3.5.5.2.6 | CTDEEP Review & Processing | 3mo | 2018-05-18 | 2018-08-10 | 104 | 163d |  |
| 106 | 3.5.5.3 | **General Coastal Maintenance (CTDEEP-OLISP)** | 20d | 2018-01-05 | 2018-02-02 |  | 298d |  |
| 107 | 3.5.5.3.1 | Draft Certificate Form | 5d | 2018-01-05 | 2018-01-12 | 11 | 298d | 0d |
| 108 | 3.5.5.3.2 | CTDOT OEP Review | 1w | 2018-01-12 | 2018-01-19 | 107 | 298d | 0d |
| 109 | 3.5.5.3.3 | Draft Revisions to Permit | 5d | 2018-01-19 | 2018-01-26 | 108 | 298d | 0d |
| 110 | 3.5.5.3.4 | CTDOT OEP Review & Processing | 1w | 2018-01-26 | 2018-02-02 | 109 | 298d |  |

| ID | WBS | Task | Duration | Start | Finish | Predecessors | Total slack | Free slack |
| --- | --- | --- | --- | --- | --- | --- | --- | --- |
| 111 | 3.5.5.4 | **Certificate of Permission (CTDEEP-OLSIP)** | 125d | 2018-01-05 | 2018-06-29 |  | 193d |  |
| 112 | 3.5.5.4.1 | Draft Certificate Form | 30d | 2018-01-05 | 2018-02-16 | 11 | 193d | 0d |
| 113 | 3.5.5.4.2 | CTDOT OEP Review | 1mo | 2018-02-16 | 2018-03-16 | 112 | 193d | 0d |
| 114 | 3.5.5.4.3 | CTDOT EPC Review | 1w | 2018-03-16 | 2018-03-23 | 113 | 193d | 0d |
| 115 | 3.5.5.4.4 | Draft Revisions to Permit | 20d | 2018-03-23 | 2018-04-20 | 114 | 193d | 0d |
| 116 | 3.5.5.4.5 | CTDOT OEP Review & Processing | 1mo | 2018-04-20 | 2018-05-18 | 115 | 193d | 0d |
| 117 | 3.5.5.4.6 | CTDEEP Review & Processing | 6w | 2018-05-18 | 2018-06-29 | 116 | 193d |  |
| 118 | 3.5.5.5 | **Structures, Dredging, Fill, Tidal Wetlands & 401 Permit (CTDEEP-OLSIP)** | 281d | 2018-01-05 | 2019-02-04 |  | 37d |  |
| 119 | 3.5.5.5.1 | Draft Permit | 30d | 2018-01-05 | 2018-02-16 | 11 | 37d | 0d |
| 120 | 3.5.5.5.2 | CTDOT OEP Review | 2mo | 2018-02-16 | 2018-04-13 | 119 | 37d | 0d |
| 121 | 3.5.5.5.3 | CTDOT EPC Review | 1w | 2018-04-13 | 2018-04-20 | 120 | 37d | 0d |
| 122 | 3.5.5.5.4 | Draft Revisions to Permit | 20d | 2018-04-20 | 2018-05-18 | 121 | 37d | 0d |
| 123 | 3.5.5.5.5 | CTDOT OEP Review & Processing | 1mo | 2018-05-18 | 2018-06-15 | 122 | 37d | 0d |
| 124 | 3.5.5.5.6 | CTDEEP Review & Processing | 6mo | 2018-06-15 | 2018-11-30 | 123 | 37d | 0d |
| 125 | 3.5.5.5.7 | Public Notice Period | 1.3mo | 2018-11-30 | 2019-01-07 | 124 | 37d | 0d |
| 126 | 3.5.5.5.8 | CTDEEP Permit Issuance | 1mo | 2019-01-07 | 2019-02-04 | 125 | 37d |  |
| 127 | 3.5.6 | **Dam Permits (CTDEEP-IWRD)** | 275d | 2018-01-05 | 2019-01-25 |  | 40d |  |
| 128 | 3.5.6.1 | **General Permit for Dam Safety Repair and Alteration** | 95d | 2018-01-05 | 2018-05-18 |  | 220d |  |
| 129 | 3.5.6.1.1 | Draft Permit | 30d | 2018-01-05 | 2018-02-16 | 11 | 220d | 0d |
| 130 | 3.5.6.1.2 | CTDOT OEP Review | 1mo | 2018-02-16 | 2018-03-16 | 129 | 220d | 0d |
| 131 | 3.5.6.1.3 | CTDOT EPC Review | 1w | 2018-03-16 | 2018-03-23 | 130 | 220d | 0d |
| 132 | 3.5.6.1.4 | Draft Revisions to Permit | 20d | 2018-03-23 | 2018-04-20 | 131 | 220d | 0d |
| 133 | 3.5.6.1.5 | CTDOT OEP Review & Processing | 1mo | 2018-04-20 | 2018-05-18 | 132 | 220d |  |
| 134 | 3.5.6.2 | **Individual Dam Construction Permit** | 275d | 2018-01-05 | 2019-01-25 |  | 40d |  |
| 135 | 3.5.6.2.1 | Draft Permit | 30d | 2018-01-05 | 2018-02-16 | 11 | 40d | 0d |
| 136 | 3.5.6.2.2 | CTDOT OEP Review | 2mo | 2018-02-16 | 2018-04-13 | 135 | 40d | 0d |
| 137 | 3.5.6.2.3 | CTDOT EPC Review | 1w | 2018-04-13 | 2018-04-20 | 136 | 40d | 0d |
| 138 | 3.5.6.2.4 | Draft Revisions to Permit | 20d | 2018-04-20 | 2018-05-18 | 137 | 40d | 0d |
| 139 | 3.5.6.2.5 | CTDOT OEP Review & Processing | 1mo | 2018-05-18 | 2018-06-15 | 138 | 40d | 0d |
| 140 | 3.5.6.2.6 | CTDEEP Review & Processing | 6mo | 2018-06-15 | 2018-11-30 | 139 | 40d | 0d |
| 141 | 3.5.6.2.7 | Public Notice Period | 1mo | 2018-11-30 | 2018-12-28 | 140 | 40d | 0d |
| 142 | 3.5.6.2.8 | CTDEEP Permit Issuance | 1mo | 2018-12-28 | 2019-01-25 | 141 | 40d |  |

| ID | WBS | Task | Type | Duration | Start | Finish | Predecessors | Total slack | Free slack |
| --- | --- | --- | --- | --- | --- | --- | --- | --- | --- |
| 143 | 3.5.7 | **Section 404/Section 10 Permits (USACE)** |  | 315d | 2018-01-05 | 2019-03-22 |  | 0d |  |
| 144 | 3.5.7.1 | **Self-Verification Form (CTDOT-OEP)** |  | 23d | 2018-01-05 | 2018-02-07 |  | 292d |  |
| 145 | 3.5.7.1.1 | Draft Permit |  | 5d | 2018-01-05 | 2018-01-12 | 11 | 292d | 0d |
| 146 | 3.5.7.1.2 | CTDOT OEP Review |  | 1w | 2018-01-12 | 2018-01-19 | 145 | 292d | 0d |
| 147 | 3.5.7.1.3 | Draft Revisions to Permit |  | 5d | 2018-01-19 | 2018-01-26 | 146 | 292d | 0d |
| 148 | 3.5.7.1.4 | CTDOT OEP Review & Processing |  | 1w | 2018-01-26 | 2018-02-02 | 147 | 292d | 0d |
| 149 | 3.5.7.1.5 | CTDOT OEP Permit Registration to USACE |  | 3d | 2018-02-02 | 2018-02-07 | 148 | 292d |  |
| 150 | 3.5.7.2 | **Pre-Construction Notification (PCN) - Eng. Forum 4345** |  | 295d | 2018-01-05 | 2019-02-22 |  | 20d |  |
| 151 | 3.5.7.2.1 | Draft Permit |  | 30d | 2018-01-05 | 2018-02-16 | 11 | 20d | 0d |
| 152 | 3.5.7.2.2 | CTDOT OEP Review |  | 1mo | 2018-02-16 | 2018-03-16 | 151 | 20d | 0d |
| 153 | 3.5.7.2.3 | CTDOT EPC Review |  | 1w | 2018-03-16 | 2018-03-23 | 152 | 20d | 0d |
| 154 | 3.5.7.2.4 | Draft Revisions to Permit |  | 20d | 2018-03-23 | 2018-04-20 | 153 | 20d | 0d |
| 155 | 3.5.7.2.5 | CTDOT OEP Review & Processing |  | 1mo | 2018-04-20 | 2018-05-18 | 154 | 20d | 0d |
| 156 | 3.5.7.2.6 | USACE Review, Processing & Certification |  | 10mo | 2018-05-18 | 2019-02-22 | 155 | 20d |  |
| 157 | 3.5.7.3 | **Individual Permit - Eng. Forum 4345** |  | 315d | 2018-01-05 | 2019-03-22 |  | 0d |  |
| 158 | 3.5.7.3.1 | Draft Permit |  | 30d | 2018-01-05 | 2018-02-16 | 11 | 0d |  |
| 159 | 3.5.7.3.2 | CTDOT OEP Review |  | 2mo | 2018-02-16 | 2018-04-13 | 158 | 0d |  |
| 160 | 3.5.7.3.3 | CTDOT EPC Review |  | 1w | 2018-04-13 | 2018-04-20 | 159 | 0d |  |
| 161 | 3.5.7.3.4 | Draft Revisions to Permit |  | 20d | 2018-04-20 | 2018-05-18 | 160 | 0d |  |
| 162 | 3.5.7.3.5 | CTDOT OEP Review & Processing |  | 1mo | 2018-05-18 | 2018-06-15 | 161 | 0d |  |
| 163 | 3.5.7.3.6 | USACE Review & Processing |  | 8mo | 2018-06-15 | 2019-01-25 | 162 | 0d |  |
| 164 | 3.5.7.3.7 | Public Notice Period |  | 1mo | 2019-01-25 | 2019-02-22 | 163 | 0d |  |
| 165 | 3.5.7.3.8 | USACE Permit Issuance |  | 1mo | 2019-02-22 | 2019-03-22 | 164 | 0d |  |
| 166 | 3.5.8 | **United States Coast Guard (USCG)** |  | 315d | 2018-01-05 | 2019-03-22 |  | 0d |  |
| 167 | 3.5.8.1 | Draft Permit |  | 30d | 2018-01-05 | 2018-02-16 | 11 | 0d |  |
| 168 | 3.5.8.2 | CTDOT OEP Review |  | 2mo | 2018-02-16 | 2018-04-13 | 167 | 0d |  |
| 169 | 3.5.8.3 | CTDOT EPC Review |  | 1w | 2018-04-13 | 2018-04-20 | 168 | 0d |  |
| 170 | 3.5.8.4 | Draft Revisions to Permit |  | 20d | 2018-04-20 | 2018-05-18 | 169 | 0d |  |
| 171 | 3.5.8.5 | CTDOT OEP Review & Processing |  | 1mo | 2018-05-18 | 2018-06-15 | 170 | 0d |  |
| 172 | 3.5.8.6 | USCG Review & Processing |  | 8mo | 2018-06-15 | 2019-01-25 | 171 | 0d |  |
| 173 | 3.5.8.7 | Public Notice Period |  | 1mo | 2019-01-25 | 2019-02-22 | 172 | 0d |  |
| 174 | 3.5.8.8 | USCG Permit Issuance |  | 1mo | 2019-02-22 | 2019-03-22 | 173 | 0d |  |
| 175 | 4 | FDP | milestone | 0mo | 2019-03-27 | 2019-03-27 | 15, 18, 23, 33, 40, 49, 57, 66, 74, 83, 94, 98, 105, 110, 117, 126, 133, 142, 156, 165, 174, 149 | 0d |  |
| 176 | 5 | DCD | milestone | 0mo | 2019-05-08 | 2019-05-08 | 175FS+6ew | 0d |  |
| 177 | 6 | ADV | milestone | 0mo | 2019-06-05 | 2019-06-05 | 176FS+4ew | 0d |  |
